# part2

Schedule from MS Project, 2004-01-05 to 2004-11-19, costs in $.

## Calendars

- Standard: Mon-Fri 08:00-12:00, 13:00-17:00; Sat-Sun off.

## Resources

| Resource | Group | Rate |
| --- | --- | --- |
| RDK | Team Leader | 150 |
| CEK | Design Lead | 120 |
| ARB | Programmers | 100 |
| JTP | Programmers | 100 |
| DLC | Programmers | 100 |
| MLM | Test Engineer | 120 |
| BRD | Test Engineer | 100 |
| HLQ | Test Engineer | 100 |

## Schedule

| ID | WBS | Task | Duration | Start | Finish | Predecessors | Baseline start | Baseline finish | Baseline duration | Total slack | Resources | Work | Cost | Baseline cost |
| --- | --- | --- | --- | --- | --- | --- | --- | --- | --- | --- | --- | --- | --- | --- |
| 1 | 1 | **Requirements Phase** | 65.5d? | 2004-01-05 | 2004-04-05 |  | 2004-01-05 | 2004-04-05 | 65.5d? | 0d | RDK [80%]; CEK | 975.2h | 129,600 | 129,600 |
| 2 | 1.1 | Configuration Management Plan | 2d | 2004-01-05 | 2004-01-06 |  | 2004-01-05 | 2004-01-06 | 2d | 0d |  |  |  |  |
| 3 | 1.2 | Key users identified | 1d? | 2004-01-07 | 2004-01-07 | 2 | 2004-01-07 | 2004-01-07 | 1d? | 0d |  |  |  |  |
| 4 | 1.3 | User interviews | 7d | 2004-01-08 | 2004-01-16 | 3 | 2004-01-08 | 2004-01-16 | 7d | 0d |  |  |  |  |
| 5 | 1.4 | Use cases developed | 7d | 2004-01-19 | 2004-01-27 | 4 | 2004-01-19 | 2004-01-27 | 7d | 0d |  |  |  |  |
| 6 | 1.5 | User interface prototyped developed & approved | 14d | 2004-01-28 | 2004-02-16 | 5 | 2004-01-28 | 2004-02-16 | 14d | 0d |  |  |  |  |
| 7 | 1.6 | Functional requirements writing | 20d | 2004-02-17 | 2004-03-15 | 6 | 2004-02-17 | 2004-03-15 | 20d | 0d |  |  |  |  |
| 8 | 1.7 | Project master test plan | 5d | 2004-03-16 | 2004-03-22 | 7 | 2004-03-16 | 2004-03-22 | 5d | 0d | MLM [80%] | 32h | 3,840 | 3,840 |
| 9 | 1.8 | Data Dictionary | 8d | 2004-03-23 | 2004-04-01 | 8 | 2004-03-23 | 2004-04-01 | 8d | 0d |  |  |  |  |
| 10 | 1.9 | Update Project Plan, refine estimates | 1.5d | 2004-04-02 | 2004-04-05 | 9 | 2004-04-02 | 2004-04-05 | 1.5d | 0d |  |  |  |  |
| 11 | 2 | **Functional Design Phase** | 32.5d? | 2004-04-05 | 2004-05-19 | 1 | 2004-04-05 | 2004-05-19 | 32.5d? | 0d | RDK [80%]; CEK | 468h | 62,400 | 62,400 |
| 12 | 2.1 | Logical Model | 4d | 2004-04-05 | 2004-04-09 |  | 2004-04-05 | 2004-04-09 | 4d | 0d |  |  |  |  |
| 13 | 2.2 | Data Dictionary | 2d | 2004-04-09 | 2004-04-13 | 12 | 2004-04-09 | 2004-04-13 | 2d | 0d |  |  |  |  |
| 14 | 2.3 | Requirements Traceability Matrix | 2d | 2004-04-13 | 2004-04-15 | 13 | 2004-04-13 | 2004-04-15 | 2d | 0d |  |  |  |  |
| 15 | 2.4 | Software Architecture | 5d | 2004-04-15 | 2004-04-22 | 14 | 2004-04-15 | 2004-04-22 | 5d | 0d |  |  |  |  |
| 16 | 2.5 | Functional Design Document | 18.5d | 2004-04-22 | 2004-05-18 | 15 | 2004-04-22 | 2004-05-18 | 18.5d | 0d |  |  |  |  |
| 17 | 2.6 | Update project plan, refine estimates | 1d? | 2004-05-19 | 2004-05-19 | 16 | 2004-05-19 | 2004-05-19 | 1d? | 0d |  |  |  |  |
| 18 | 3 | **System Design Phase** | 34d? | 2004-05-20 | 2004-07-06 | 11 | 2004-01-05 | 2004-02-19 | 34d? | 0d | RDK [80%] | 268.8h | 38,784 | 38,784 |
| 19 | 3.1 | Physical Model | 5d | 2004-05-20 | 2004-05-26 |  | 2004-01-05 | 2004-01-09 | 5d | 0d |  |  |  |  |
| 20 | 3.2 | Integration Test Plan | 2d | 2004-05-27 | 2004-05-28 | 19 | 2004-01-12 | 2004-01-13 | 2d | 0d | MLM [80%] | 12.8h | 1,536 | 1,536 |
| 21 | 3.3 | System Test Plan | 5d | 2004-05-31 | 2004-06-04 | 20 | 2004-01-14 | 2004-01-20 | 5d | 0d | MLM [80%] | 32h | 3,840 | 3,840 |
| 22 | 3.4 | Subsystem Specifications | 20d | 2004-06-07 | 2004-07-02 | 21 | 2004-01-21 | 2004-02-17 | 20d | 0d |  |  |  |  |
| 23 | 3.5 | Programming Standards | 1d? | 2004-07-05 | 2004-07-05 | 22 | 2004-02-18 | 2004-02-18 | 1d? | 0d |  |  |  |  |
| 24 | 3.6 | Update project plan, refine estimates | 1d? | 2004-07-06 | 2004-07-06 | 23 | 2004-02-19 | 2004-02-19 | 1d? | 0d | MLM [80%] | 6.4h | 768 | 768 |

| ID | WBS | Task | Type | Duration | Start | Finish | Predecessors | Baseline start | Baseline finish | Baseline duration | Total slack | Free slack | Resources | Work | Cost | Baseline cost |
| --- | --- | --- | --- | --- | --- | --- | --- | --- | --- | --- | --- | --- | --- | --- | --- | --- |
| 25 | 4 | **Programming Phase** |  | 62.5d | 2004-07-07 | 2004-10-01 | 18 | 2004-02-20 | 2004-05-18 | 62.5d | 0d |  |  | 694.4h | 72,832 | 72,832 |
| 26 | 4.1 | Acceptance Test Plan |  | 8d | 2004-07-07 | 2004-07-16 |  | 2004-02-20 | 2004-03-02 | 8d | 0d |  | MLM [80%] | 51.2h | 6,144 | 6,144 |
| 27 | 4.2 | Integration Test Plan |  | 8.5d | 2004-07-19 | 2004-07-29 | 26 | 2004-03-03 | 2004-03-15 | 8.5d | 0d |  | MLM [80%] | 54.4h | 6,528 | 6,528 |
| 28 | 4.3 | System Test Plan |  | 10d | 2004-07-29 | 2004-08-12 | 27 | 2004-03-15 | 2004-03-29 | 10d | 0d |  | MLM [80%] | 64h | 7,680 | 7,680 |
| 29 | 4.4 | **Subsystem X1** |  | 36d | 2004-08-12 | 2004-10-01 | 28 | 2004-03-29 | 2004-05-18 | 36d | 0d |  | ARB [80%] | 230.4h | 23,040 | 23,040 |
| 30 | 4.4.1 | code and document |  | 14.5d | 2004-08-12 | 2004-09-01 |  | 2004-03-29 | 2004-04-16 | 14.5d | 0d |  |  |  |  |  |
| 31 | 4.4.2 | test and debug |  | 21.5d | 2004-09-02 | 2004-10-01 | 30 | 2004-04-19 | 2004-05-18 | 21.5d | 0d |  |  |  |  |  |
| 32 | 4.5 | **Subsystem X2** |  | 21d | 2004-07-07 | 2004-08-04 |  | 2004-02-20 | 2004-03-19 | 21d | 41.5d |  | JTP [80%] | 134.4h | 13,440 | 13,440 |
| 33 | 4.5.1 | code and document |  | 8.5d | 2004-07-07 | 2004-07-19 |  | 2004-02-20 | 2004-03-03 | 8.5d | 41.5d | 0d |  |  |  |  |
| 34 | 4.5.2 | test and debug |  | 12.5d | 2004-07-19 | 2004-08-04 | 33 | 2004-03-03 | 2004-03-19 | 12.5d | 41.5d |  |  |  |  |  |
| 35 | 4.6 | **Subsystem X3** |  | 25d | 2004-07-07 | 2004-08-10 |  | 2004-02-20 | 2004-03-25 | 25d | 37.5d |  | DLC [80%] | 160h | 16,000 | 16,000 |
| 36 | 4.6.1 | code and document |  | 10d | 2004-07-07 | 2004-07-20 |  | 2004-02-20 | 2004-03-04 | 10d | 37.5d | 0d |  |  |  |  |
| 37 | 4.6.2 | test and debug |  | 15d | 2004-07-21 | 2004-08-10 | 36 | 2004-03-05 | 2004-03-25 | 15d | 37.5d |  |  |  |  |  |
| 38 | 5 | **System Integration and Testing Phase** |  | 30d | 2004-10-01 | 2004-11-12 | 25 | 2004-05-18 | 2004-06-29 | 30d | 0d |  |  | 281.6h | 28,416 | 28,416 |
| 39 | 5.1 | System integration and integration testing |  | 8d | 2004-10-01 | 2004-10-13 |  | 2004-05-18 | 2004-05-28 | 8d | 0d |  | BRD [80%]; HLQ [40%] | 76.8h | 7,680 | 7,680 |
| 40 | 5.2 | System test execution and reporting |  | 20d | 2004-10-13 | 2004-11-10 | 39 | 2004-05-28 | 2004-06-25 | 20d | 0d |  | BRD [80%]; HLQ [40%] | 192h | 19,200 | 19,200 |
| 41 | 5.3 | Acceptance Test Plan |  | 2d | 2004-11-10 | 2004-11-12 | 40 | 2004-06-25 | 2004-06-29 | 2d | 0d |  | MLM [80%] | 12.8h | 1,536 | 1,536 |
| 42 | 6 | **Installation and Acceptance Phase** |  | 5.33d | 2004-11-12 | 2004-11-19 | 38 | 2004-06-29 | 2004-07-06 | 5.33d | 0d |  |  | 44.8h | 4,736 | 4,736 |
| 43 | 6.1 | System Installation |  | 2d | 2004-11-12 | 2004-11-16 |  | 2004-06-29 | 2004-07-01 | 2d | 0d |  | MLM [80%] | 12.8h | 1,536 | 1,536 |
| 44 | 6.2 | Acceptance Test |  | 3.33d | 2004-11-16 | 2004-11-19 | 43 | 2004-07-01 | 2004-07-06 | 3.33d | 0d |  | BRD [80%]; HLQ [40%] | 32h | 3,200 | 3,200 |
| 45 | 6.3 | Operational System | milestone | 0d | 2004-11-19 | 2004-11-19 | 44 | 2004-07-06 | 2004-07-06 | 0d | 0d |  |  |  |  |  |
